# Cronograma preliminar2 Diseño proceso Certicamara v1

Schedule from MS Project, 2019-10-18 to 2022-01-26, status date 2020-09-20, 4 hours a day, costs in $, A marks actual dates.

## Calendars

- calendario proyecto Certicamara: Mon-Fri 08:00-12:00; Sat-Sun off. Exceptions (off unless hours are given): 2019-11-04 (Festivo 4 Noviembre 19), 2019-11-11 (Festivo Noviembre 11), 2019-12-13 to 2020-01-16 (Vacaciones Colectivas), 2020-03-23 (Festivo Marzo 20), 2020-04-09 to 2020-04-10 (Festivo Abril 20), 2020-05-01 (Festivo Mayo 20), 2020-05-25 (Festivo mayo 20), 2020-06-15 (Festivo Junio 20), 2020-06-22 (Festivo Junio 20), 2020-06-29 (Festivo Junio 20), 2020-07-20 (Festivo Julio 20), 2020-08-07 (Festivo Agosto 20), 2020-08-17 (Festivo Agosto 20), 2020-10-12 (Festivo Octubre 20), 2020-11-02 (Festivo 1 Noviembre), 2020-11-16 (Festivo 2 Noviembre), 2020-11-17 to 2020-12-31 (Vacaciones colectivas), 2021-01-01 (festivo enero 2021), 2021-01-11 (Festivo 2 Enero), 2021-03-22 (Festivo 1 Marzo), 2021-04-01 (Festivo 1 Abril), 2021-04-02 (Festivo 2 Abril), 2021-05-17 (Festivo 1 mayo), 2021-06-07 (Festivo 1 Junio), 2021-06-14 (Festivo 2 Junio), 2021-07-05 (Festivo 1 Julio), 2021-07-20 (Festivo 2 Julio), 2021-08-16 (Festivo 1 Agosto), 2021-10-18 (Festivo 1 Octubre), 2021-11-01 (Festivo 1 Noviembre 21), 2021-11-15 (Festivo 2 Noviembre 21), 2021-12-08 to 2021-12-31 (Vacaciones colectivas 2020), 2022-01-10 (Festivo 1 enero 2022).

## Resources

| Resource | Rate |
| --- | --- |
| Líder Técnico | 43750 |
| Líder Funcional | 43750 |
| Director de proyecto | 43750 |
| Dotación DP |  |
| Dotación LT |  |
| Dotación LF |  |
| Impresora |  |
| Scanner |  |
| Hojas tamaño carta |  |
| Marcadores para tablero |  |
| Firma digital |  |
| Certicámara |  |
| Líder Técnico - en Planeación | 12500 |
| Líder Funcional - En Planeación | 12500 |
| Director de proyecto -En Planeación | 12500 |

## Schedule

| ID | WBS | Task | Type | Duration | Start | Finish | Predecessors | Complete | Baseline start | Baseline finish | Baseline duration | Resources | Work | Actual work | Cost | Baseline cost | Actual cost |
| --- | --- | --- | --- | --- | --- | --- | --- | --- | --- | --- | --- | --- | --- | --- | --- | --- | --- |
| 1 | 1 | **PRELIMINAR** |  | 17d | 2019-10-18 A | 2019-11-13 A |  | 100% | 2019-10-18 | 2019-11-13 | 17d |  | 68h | 68h | 850,000 | 850,000 | 850,000 |
| 2 | 1.1 | **Documento de iniciativa interna** |  | 17d | 2019-10-18 A | 2019-11-13 A |  | 100% | 2019-10-18 | 2019-11-13 | 17d |  | 68h | 68h | 850,000 | 850,000 | 850,000 |
| 3 | 1.1.1 | Elaboración de documento de inciativa interna |  | 40h | 2019-10-18 A | 2019-10-31 A |  | 100% | 2019-10-18 | 2019-10-31 | 40h | Director de proyecto -En Planeación | 40h | 40h | 500,000 | 500,000 | 500,000 |
| 4 | 1.1.2 | Correcciones al documento de Iniciativa |  | 4h | 2019-11-01 A | 2019-11-01 A | 3 | 100% | 2019-11-01 | 2019-11-01 | 4h | Líder Funcional - En Planeación | 4h | 4h | 50,000 | 50,000 | 50,000 |
| 5 | 1.1.3 | Presentación documento de inciativa interna a comité |  | 2h | 2019-11-05 A | 2019-11-05 A | 4 | 100% | 2019-11-05 | 2019-11-05 | 2h | Líder Técnico - en Planeación | 2h | 2h | 25,000 | 25,000 | 25,000 |
| 6 | 1.1.4 | Sesion de aclaraciones de la iniciativa |  | 2h | 2019-11-05 A | 2019-11-05 A | 5 | 100% | 2019-11-05 | 2019-11-05 | 2h | Líder Técnico - en Planeación | 2h | 2h | 25,000 | 25,000 | 25,000 |
| 7 | 1.1.5 | Aprobacion de la iniciativa por parte del comité |  | 12h | 2019-11-06 A | 2019-11-08 A | 6 | 100% | 2019-11-06 | 2019-11-08 | 12h | Líder Funcional - En Planeación | 12h | 12h | 150,000 | 150,000 | 150,000 |
| 8 | 1.1.6 | Firma de acuerdo de confidencialidad por parte del equipo del proyecto |  | 4h | 2019-11-12 A | 2019-11-12 A | 7 | 100% | 2019-11-12 | 2019-11-12 | 4h | Líder Técnico - en Planeación | 4h | 4h | 50,000 | 50,000 | 50,000 |
| 9 | 1.1.7 | Reunión para generar acta |  | 4h | 2019-11-13 A | 2019-11-13 A | 8 | 100% | 2019-11-13 | 2019-11-13 | 4h | Director de proyecto -En Planeación | 4h | 4h | 50,000 | 50,000 | 50,000 |
| 10 | 1.1.8 | Firma del documento de iniciativa interna | milestone | 0h | 2019-11-13 A | 2019-11-13 A | 9 | 100% | 2019-11-13 | 2019-11-13 | 0h |  |  |  |  |  |  |
| 11 | 2 | **INICIO** |  | 6d | 2019-11-14 A | 2019-11-21 A |  | 100% | 2019-11-14 | 2019-11-21 | 6d |  | 24h | 24h | 300,000 | 300,000 | 300,000 |
| 12 | 2.1 | **Kick Off interno** |  | 6d | 2019-11-14 A | 2019-11-21 A |  | 100% | 2019-11-14 | 2019-11-21 | 6d |  | 24h | 24h | 300,000 | 300,000 | 300,000 |
| 13 | 2.1.1 | Identificar a Todos los Interesados |  | 20h | 2019-11-14 A | 2019-11-20 A | 10 | 100% | 2019-11-14 | 2019-11-20 | 20h | Líder Funcional - En Planeación | 20h | 20h | 250,000 | 250,000 | 250,000 |
| 14 | 2.1.2 | Reunión KickOff Interno |  | 4h | 2019-11-21 A | 2019-11-21 A | 13 | 100% | 2019-11-21 | 2019-11-21 | 4h | Líder Técnico - en Planeación | 4h | 4h | 50,000 | 50,000 | 50,000 |
| 15 | 2.1.3 | Acta de Reunión KickOff Interno | milestone | 0h | 2019-11-21 A | 2019-11-21 A | 14 | 100% | 2019-11-21 | 2019-11-21 | 0h |  |  |  |  |  |  |
| 16 | 3 | **PLANEACION** |  | 196.25d | 2019-11-22 A | 2020-10-14 A |  | 100% | 2019-11-22 | 2020-10-14 | 196.25d |  | 899h | 899h | 11,237,500 | 11,237,500 | 11,237,500 |
| 17 | 3.1 | **Project Charter** |  | 30.75d | 2019-11-22 A | 2020-02-07 A |  | 100% | 2019-11-22 | 2020-02-07 | 30.75d |  | 122h | 122h | 1,525,000 | 1,525,000 | 1,525,000 |
| 18 | 3.1.1 | Generar Project Charter |  | 82h | 2019-11-22 A | 2020-01-24 A | 15 | 100% | 2019-11-22 | 2020-01-24 | 82h | Director de proyecto -En Planeación | 82h | 82h | 1,025,000 | 1,025,000 | 1,025,000 |
| 19 | 3.1.2 | Verificación de Project Charter |  | 20h | 2020-01-24 A | 2020-01-31 A | 18 | 100% | 2020-01-24 | 2020-01-31 | 20h | Líder Funcional - En Planeación; Líder Técnico - en Planeación | 40h | 40h | 500,000 | 500,000 | 500,000 |
| 20 | 3.1.3 | Aprobación de Project Charter | milestone | 0h | 2020-02-07 A | 2020-02-07 A | 19 | 100% | 2020-02-07 | 2020-02-07 | 0h |  |  |  |  |  |  |
| 21 | 3.2 | **Alcance** |  | 43d | 2020-02-07 A | 2020-04-13 A |  | 100% | 2020-02-07 | 2020-04-13 | 43d |  | 180h | 180h | 2,250,000 | 2,250,000 | 2,250,000 |
| 22 | 3.2.1 | Analisis de Datos |  | 10h | 2020-02-07 A | 2020-02-12 A | 20 | 100% | 2020-02-07 | 2020-02-12 | 10h | Líder Funcional - En Planeación; Líder Técnico - en Planeación | 20h | 20h | 250,000 | 250,000 | 250,000 |
| 23 | 3.2.2 | **Plan para Gestionar el Alcance y los requisitos** |  | 14.25d | 2020-02-14 A | 2020-03-05 A |  | 100% | 2020-02-14 | 2020-03-05 | 14.25d |  | 59h | 59h | 737,500 | 737,500 | 737,500 |
| 24 | 3.2.2.1 | Matriz de requisitos |  | 6h | 2020-02-14 A | 2020-02-18 A | 22 | 100% | 2020-02-14 | 2020-02-18 | 6h | Director de proyecto -En Planeación; Líder Técnico - en Planeación | 12h | 12h | 150,000 | 150,000 | 150,000 |
| 25 | 3.2.2.2 | Registro de Riesgos |  | 12h | 2020-02-19 A | 2020-02-24 A | 24 | 100% | 2020-02-19 | 2020-02-24 | 12h | Líder Funcional - En Planeación | 12h | 12h | 150,000 | 150,000 | 150,000 |
| 26 | 3.2.2.3 | Registro de Supuestos |  | 12h | 2020-02-24 A | 2020-02-27 A | 25 | 100% | 2020-02-24 | 2020-02-27 | 12h | Líder Técnico - en Planeación | 12h | 12h | 150,000 | 150,000 | 150,000 |
| 27 | 3.2.2.4 | Sesión de Seguimiento equipo de proyecto |  | 1h | 2020-02-27 A | 2020-02-27 A | 26 | 100% | 2020-02-27 | 2020-02-27 | 1h | Director de proyecto -En Planeación; Líder Funcional - En Planeación; Líder Técnico - en Planeación | 3h | 3h | 37,500 | 37,500 | 37,500 |
| 28 | 3.2.2.5 | Enunciado del alcance |  | 20h | 2020-02-28 A | 2020-03-05 A | 27 | 100% | 2020-02-28 | 2020-03-05 | 20h | Director de proyecto -En Planeación | 20h | 20h | 250,000 | 250,000 | 250,000 |

| ID | WBS | Task | Type | Duration | Start | Finish | Predecessors | Complete | Baseline start | Baseline finish | Baseline duration | Constraint | Resources | Work | Actual work | Cost | Baseline cost | Actual cost |
| --- | --- | --- | --- | --- | --- | --- | --- | --- | --- | --- | --- | --- | --- | --- | --- | --- | --- | --- |
| 29 | 3.2.3 | **EDT** |  | 20.5d | 2020-03-06 A | 2020-04-06 A |  | 100% | 2020-03-06 | 2020-04-06 | 20.5d |  |  | 86h | 86h | 1,075,000 | 1,075,000 | 1,075,000 |
| 30 | 3.2.3.1 | Crear EDT |  | 20h | 2020-03-06 A | 2020-03-12 A | 28 | 100% | 2020-03-06 | 2020-03-12 | 20h |  | Líder Funcional - En Planeación; Líder Técnico - en Planeación; Director de proyecto -En Planeación | 60h | 60h | 750,000 | 750,000 | 750,000 |
| 31 | 3.2.3.2 | Sesión de Seguimiento equipo de proyecto |  | 1h | 2020-03-30 A | 2020-03-30 A | 30 | 100% | 2020-03-30 | 2020-03-30 | 1h |  | Director de proyecto -En Planeación; Líder Funcional - En Planeación; Líder Técnico - en Planeación | 3h | 3h | 37,500 | 37,500 | 37,500 |
| 32 | 3.2.3.3 | Aprobar EDT | milestone | 0h | 2020-03-30 A | 2020-03-30 A | 31 | 100% | 2020-03-30 | 2020-03-30 | 0h |  | Líder Funcional - En Planeación |  |  |  |  |  |
| 33 | 3.2.3.4 | Diccionario de la EDT |  | 20h | 2020-03-30 A | 2020-04-06 A | 32 | 100% | 2020-03-30 | 2020-04-06 | 20h |  | Líder Técnico - en Planeación | 20h | 20h | 250,000 | 250,000 | 250,000 |
| 34 | 3.2.3.5 | Sesión de Seguimiento equipo de proyecto |  | 1h | 2020-04-06 A | 2020-04-06 A | 33 | 100% | 2020-04-06 | 2020-04-06 | 1h |  | Director de proyecto -En Planeación; Líder Funcional - En Planeación; Líder Técnico - en Planeación | 3h | 3h | 37,500 | 37,500 | 37,500 |
| 35 | 3.2.3.6 | Aprobar Diccionario de la EDT | milestone | 0h | 2020-04-06 A | 2020-04-06 A | 34 | 100% | 2020-04-06 | 2020-04-06 | 0h |  |  |  |  |  |  |  |
| 36 | 3.2.4 | **Línea Base del Alcance** |  | 3.25d | 2020-04-06 A | 2020-04-13 A |  | 100% | 2020-04-06 | 2020-04-13 | 3.25d |  |  | 15h | 15h | 187,500 | 187,500 | 187,500 |
| 37 | 3.2.4.1 | Aceptación de Entregables |  | 12h | 2020-04-06 A | 2020-04-13 A | 29 | 100% | 2020-04-06 | 2020-04-13 | 12h |  | Líder Funcional - En Planeación | 12h | 12h | 150,000 | 150,000 | 150,000 |
| 38 | 3.2.4.2 | Aprobación de línea Base del Alcance | milestone | 0h | 2020-04-13 A | 2020-04-13 A | 37 | 100% | 2020-04-13 | 2020-04-13 | 0h |  |  |  |  |  |  |  |
| 39 | 3.2.4.3 | Sesión de Seguimiento equipo de proyecto |  | 1h | 2020-04-13 A | 2020-04-13 A | 38 | 100% | 2020-04-13 | 2020-04-13 | 1h |  | Director de proyecto -En Planeación; Líder Funcional - En Planeación; Líder Técnico - en Planeación | 3h | 3h | 37,500 | 37,500 | 37,500 |
| 40 | 3.3 | **Plan de Gestión las comunicaciones y los Interesados** |  | 10.25d | 2020-04-13 A | 2020-04-27 A |  | 100% | 2020-04-13 | 2020-04-27 | 10.25d |  |  | 43h | 43h | 537,500 | 537,500 | 537,500 |
| 41 | 3.3.1 | Generar plan de Involucramiento de los Interesados |  | 10h | 2020-04-13 A | 2020-04-15 A | 38 | 100% | 2020-04-13 | 2020-04-15 | 10h | finish no earlier than 2019-10-18 | Líder Funcional - En Planeación; Líder Técnico - en Planeación | 20h | 20h | 250,000 | 250,000 | 250,000 |
| 42 | 3.3.2 | Planificar la gestión de las Comunicaciones |  | 20h | 2020-04-20 A | 2020-04-27 A | 41 | 100% | 2020-04-20 | 2020-04-27 | 20h |  | Director de proyecto -En Planeación | 20h | 20h | 250,000 | 250,000 | 250,000 |
| 43 | 3.3.3 | Sesión de Seguimiento equipo de proyecto |  | 1h | 2020-04-27 A | 2020-04-27 A | 42 | 100% | 2020-04-27 | 2020-04-27 | 1h |  | Director de proyecto -En Planeación; Líder Funcional - En Planeación; Líder Técnico - en Planeación | 3h | 3h | 37,500 | 37,500 | 37,500 |
| 44 | 3.3.4 | Entrega del Plan de Gestión de los interesados | milestone | 0h | 2020-04-27 A | 2020-04-27 A | 42 | 100% | 2020-04-27 | 2020-04-27 | 0h |  |  |  |  |  |  |  |
| 45 | 3.4 | **Plan de Adquisiciones** |  | 5d | 2020-04-27 A | 2020-05-05 A |  | 100% | 2020-04-27 | 2020-05-05 | 5d |  |  | 20h | 20h | 250,000 | 250,000 | 250,000 |
| 46 | 3.4.1 | Generar el Plan de Gestión de Adquisiciones |  | 20h | 2020-04-27 A | 2020-05-05 A | 44 | 100% | 2020-04-27 | 2020-05-05 | 20h |  | Líder Técnico - en Planeación | 20h | 20h | 250,000 | 250,000 | 250,000 |
| 47 | 3.4.2 | Entrega de Plan de Adquisiciones | milestone | 0h | 2020-05-05 A | 2020-05-05 A | 46 | 100% | 2020-05-05 | 2020-05-05 | 0h |  |  |  |  |  |  |  |
| 48 | 3.5 | **Cronograma** |  | 15.25d | 2020-05-05 A | 2020-05-27 A |  | 100% | 2020-05-05 | 2020-05-27 | 15.25d |  |  | 63h | 63h | 787,500 | 787,500 | 787,500 |
| 49 | 3.5.1 | Establecer tiempos de las actividades |  | 10h | 2020-05-05 A | 2020-05-07 A | 47 | 100% | 2020-05-05 | 2020-05-07 | 10h |  | Director de proyecto -En Planeación; Líder Funcional - En Planeación | 20h | 20h | 250,000 | 250,000 | 250,000 |
| 50 | 3.5.2 | Secuenciar Actividades |  | 14h | 2020-05-12 A | 2020-05-15 A | 49 | 100% | 2020-05-12 | 2020-05-15 | 14h |  | Director de proyecto -En Planeación; Líder Técnico - en Planeación | 28h | 28h | 350,000 | 350,000 | 350,000 |
| 51 | 3.5.3 | Línea Base del Cronograma | milestone | 0h | 2020-05-21 A | 2020-05-21 A | 50 | 100% | 2020-05-21 | 2020-05-21 | 0h |  |  |  |  |  |  |  |
| 52 | 3.5.4 | Aceptación de Entregables |  | 12h | 2020-05-21 A | 2020-05-27 A | 51 | 100% | 2020-05-21 | 2020-05-27 | 12h |  | Director de proyecto -En Planeación | 12h | 12h | 150,000 | 150,000 | 150,000 |
| 53 | 3.5.5 | Sesión de Seguimiento equipo de proyecto |  | 1h | 2020-05-27 A | 2020-05-27 A | 52 | 100% | 2020-05-27 | 2020-05-27 | 1h |  | Director de proyecto -En Planeación; Líder Funcional - En Planeación; Líder Técnico - en Planeación | 3h | 3h | 37,500 | 37,500 | 37,500 |
| 54 | 3.5.6 | Aprobación de línea Base del Cronograma | milestone | 0h | 2020-05-27 A | 2020-05-27 A | 52 | 100% | 2020-05-27 | 2020-05-27 | 0h |  |  |  |  |  |  |  |

| ID | WBS | Task | Type | Duration | Start | Finish | Predecessors | Complete | Baseline start | Baseline finish | Baseline duration | Resources | Work | Actual work | Cost | Baseline cost | Actual cost |
| --- | --- | --- | --- | --- | --- | --- | --- | --- | --- | --- | --- | --- | --- | --- | --- | --- | --- |
| 55 | 3.6 | **Costos** |  | 8.25d | 2020-05-27 A | 2020-06-08 A |  | 100% | 2020-05-27 | 2020-06-08 | 8.25d |  | 35h | 35h | 437,500 | 437,500 | 437,500 |
| 56 | 3.6.1 | Estimar los costos |  | 10h | 2020-05-27 A | 2020-05-29 A | 54 | 100% | 2020-05-27 | 2020-05-29 | 10h | Director de proyecto -En Planeación; Líder Funcional - En Planeación | 20h | 20h | 250,000 | 250,000 | 250,000 |
| 57 | 3.6.2 | **Línea Base del Costo** |  | 3.25d | 2020-06-03 A | 2020-06-08 A |  | 100% | 2020-06-03 | 2020-06-08 | 3.25d |  | 15h | 15h | 187,500 | 187,500 | 187,500 |
| 58 | 3.6.2.1 | Aceptación de Entregables |  | 12h | 2020-06-03 A | 2020-06-08 A | 56 | 100% | 2020-06-03 | 2020-06-08 | 12h | Líder Técnico - en Planeación | 12h | 12h | 150,000 | 150,000 | 150,000 |
| 59 | 3.6.2.2 | Sesión de Seguimiento equipo de proyecto |  | 1h | 2020-06-08 A | 2020-06-08 A | 58 | 100% | 2020-06-08 | 2020-06-08 | 1h | Director de proyecto -En Planeación; Líder Funcional - En Planeación; Líder Técnico - en Planeación | 3h | 3h | 37,500 | 37,500 | 37,500 |
| 60 | 3.6.2.3 | Aprobación de línea Base del Costo | milestone | 0h | 2020-06-08 A | 2020-06-08 A | 58 | 100% | 2020-06-08 | 2020-06-08 | 0h |  |  |  |  |  |  |
| 61 | 3.7 | **Plan de Riesgos** |  | 10.25d | 2020-06-08 A | 2020-06-24 A |  | 100% | 2020-06-08 | 2020-06-24 | 10.25d |  | 43h | 43h | 537,500 | 537,500 | 537,500 |
| 62 | 3.7.1 | Identificar Riesgos |  | 10h | 2020-06-08 A | 2020-06-10 A | 60 | 100% | 2020-06-08 | 2020-06-10 | 10h | Director de proyecto -En Planeación | 10h | 10h | 125,000 | 125,000 | 125,000 |
| 63 | 3.7.2 | Analisis Cualitativo |  | 10h | 2020-06-11 A | 2020-06-16 A | 62 | 100% | 2020-06-11 | 2020-06-16 | 10h | Líder Funcional - En Planeación | 10h | 10h | 125,000 | 125,000 | 125,000 |
| 64 | 3.7.3 | Analisis Cuantitativo |  | 10h | 2020-06-16 A | 2020-06-18 A | 63 | 100% | 2020-06-16 | 2020-06-18 | 10h | Líder Técnico - en Planeación | 10h | 10h | 125,000 | 125,000 | 125,000 |
| 65 | 3.7.4 | Planificar respuesta al Riesgo |  | 10h | 2020-06-19 A | 2020-06-24 A | 64 | 100% | 2020-06-19 | 2020-06-24 | 10h | Director de proyecto -En Planeación | 10h | 10h | 125,000 | 125,000 | 125,000 |
| 66 | 3.7.5 | Sesión de Seguimiento equipo de proyecto |  | 1h | 2020-06-24 A | 2020-06-24 A | 65 | 100% | 2020-06-24 | 2020-06-24 | 1h | Director de proyecto -En Planeación; Líder Funcional - En Planeación; Líder Técnico - en Planeación | 3h | 3h | 37,500 | 37,500 | 37,500 |
| 67 | 3.7.6 | Entrega del Plan de respuesta al riesgo | milestone | 0h | 2020-06-24 A | 2020-06-24 A | 65 | 100% | 2020-06-24 | 2020-06-24 | 0h |  |  |  |  |  |  |
| 68 | 3.8 | **Plan de Calidad** |  | 30.25d | 2020-06-24 A | 2020-08-10 A |  | 100% | 2020-06-24 | 2020-08-10 | 30.25d |  | 123h | 123h | 1,537,500 | 1,537,500 | 1,537,500 |
| 69 | 3.8.1 | Planificar la Gestión de la calidad |  | 60h | 2020-06-24 A | 2020-07-16 A | 67 | 100% | 2020-06-24 | 2020-07-16 | 60h | Líder Funcional - En Planeación; Líder Técnico - en Planeación | 120h | 120h | 1,500,000 | 1,500,000 | 1,500,000 |
| 70 | 3.8.2 | Sesión de Seguimiento equipo de proyecto |  | 1h | 2020-08-10 A | 2020-08-10 A | 69 | 100% | 2020-08-10 | 2020-08-10 | 1h | Director de proyecto -En Planeación; Líder Funcional - En Planeación; Líder Técnico - en Planeación | 3h | 3h | 37,500 | 37,500 | 37,500 |
| 71 | 3.8.3 | Entrega plan de Calidad | milestone | 0h | 2020-08-10 A | 2020-08-10 A | 69 | 100% | 2020-08-10 | 2020-08-10 | 0h |  |  |  |  |  |  |
| 72 | 3.9 | **Plan de Recursos** |  | 11d | 2020-08-10 A | 2020-08-26 A |  | 100% | 2020-08-10 | 2020-08-26 | 11d |  | 132h | 132h | 1,650,000 | 1,650,000 | 1,650,000 |
| 73 | 3.9.1 | Estimar los Recursos de las Actividades |  | 43h | 2020-08-10 A | 2020-08-26 A | 71 | 100% | 2020-08-10 | 2020-08-26 | 43h | Director de proyecto -En Planeación; Líder Funcional - En Planeación; Líder Técnico - en Planeación | 129h | 129h | 1,612,500 | 1,612,500 | 1,612,500 |
| 74 | 3.9.2 | Sesión de Seguimiento equipo de proyecto |  | 1h | 2020-08-26 A | 2020-08-26 A | 73 | 100% | 2020-08-26 | 2020-08-26 | 1h | Director de proyecto -En Planeación; Líder Funcional - En Planeación; Líder Técnico - en Planeación | 3h | 3h | 37,500 | 37,500 | 37,500 |
| 75 | 3.9.3 | Entregar plan de Gestión de los recursos | milestone | 0h | 2020-08-26 A | 2020-08-26 A | 74 | 100% | 2020-08-26 | 2020-08-26 | 0h |  |  |  |  |  |  |
| 76 | 3.10 | Aceptación de Entregables | milestone | 0h | 2020-08-26 A | 2020-08-26 A | 75 | 100% | 2020-08-26 | 2020-08-26 | 0h |  |  |  |  |  |  |
| 77 | 3.11 | Consolidar el plan de Dirección del Proyecto |  | 80h | 2020-08-26 A | 2020-09-23 A | 76 | 100% | 2020-08-26 | 2020-09-23 | 80h | Director de proyecto -En Planeación | 80h | 80h | 1,000,000 | 1,000,000 | 1,000,000 |
| 78 | 3.12 | Sesión de Seguimiento equipo de proyecto |  | 1h | 2020-09-23 A | 2020-09-23 A | 77 | 100% | 2020-09-23 | 2020-09-23 | 1h | Director de proyecto -En Planeación; Líder Funcional - En Planeación; Líder Técnico - en Planeación | 3h | 3h | 37,500 | 37,500 | 37,500 |
| 79 | 3.13 | Sesión de socializacion del plan para la dirección del proyecto |  | 20h | 2020-09-23 A | 2020-09-30 A | 77 | 100% | 2020-09-23 | 2020-09-30 | 20h | Líder Técnico - en Planeación | 20h | 20h | 250,000 | 250,000 | 250,000 |
| 80 | 3.14 | Acta de Socialización | milestone | 0h | 2020-09-30 A | 2020-09-30 A | 79 | 100% | 2020-09-30 | 2020-09-30 | 0h |  |  |  |  |  |  |
| 81 | 3.15 | Actualizaciones a Documentos del Proyecto |  | 35h | 2020-09-30 A | 2020-10-14 A | 80 | 100% | 2020-09-30 | 2020-10-14 | 35h | Líder Funcional - En Planeación | 35h | 35h | 437,500 | 437,500 | 437,500 |

| ID | WBS | Task | Duration | Start | Finish | Predecessors | Baseline start | Baseline finish | Baseline duration | Total slack | Free slack | Resources | Work | Cost | Baseline cost |
| --- | --- | --- | --- | --- | --- | --- | --- | --- | --- | --- | --- | --- | --- | --- | --- |
| 82 | 4 | **EJECUCION** | 234.88d | 2021-01-15 | 2022-01-24 |  | 2021-01-15 | 2022-01-24 | 234.88d | 0d |  |  | 1007.5h | 75,801,999.86 | 75,801,999.86 |
| 83 | 4.1 | **Ejecutar las Adquisiciones** | 13.75d | 2021-01-15 | 2021-02-03 |  | 2021-01-15 | 2021-02-03 | 13.75d | 0d |  |  | 65h | 2,926,866 | 2,926,866 |
| 84 | 4.1.1 | **Equipos de Computo** | 4d | 2021-01-15 | 2021-01-21 |  | 2021-01-15 | 2021-01-21 | 4d | 0d |  |  | 18h | 808,279 | 808,279 |
| 85 | 4.1.1.1 | Seleccionar proveedor | 4h | 2021-01-15 | 2021-01-18 | 81FS+30d | 2021-01-15 | 2021-01-18 | 4h | 0d |  | Certicámara [0.1%]; Director de proyecto; Líder Técnico | 8h | 350,000 | 350,000 |
| 86 | 4.1.1.2 | Contratar | 4h | 2021-01-18 | 2021-01-19 | 85 | 2021-01-18 | 2021-01-19 | 4h | 0d |  | Líder Técnico; Certicámara [0.1%] | 4h | 175,000 | 175,000 |
| 87 | 4.1.1.3 | Aprobaciones de Contrato | 2h | 2021-01-19 | 2021-01-20 | 86 | 2021-01-19 | 2021-01-20 | 2h | 0d |  | Líder Técnico; Certicámara [0.1%]; Firma digital [0.1%] | 2h | 108,279 | 108,279 |
| 88 | 4.1.1.4 | Recibir Computadores | 4h | 2021-01-20 | 2021-01-21 | 87 | 2021-01-20 | 2021-01-21 | 4h | 0d |  | Líder Técnico; Certicámara [0.1%] | 4h | 175,000 | 175,000 |
| 89 | 4.1.2 | **Licencias Software** | 3.25d | 2021-01-21 | 2021-01-26 |  | 2021-01-21 | 2021-01-26 | 3.25d | 0d |  |  | 13h | 589,529 | 589,529 |
| 90 | 4.1.2.1 | Seleccionar proveedor | 4h | 2021-01-21 | 2021-01-25 | 88 | 2021-01-21 | 2021-01-25 | 4h | 0d |  | Certicámara [0.1%]; Director de proyecto; Líder Funcional | 8h | 350,000 | 350,000 |
| 91 | 4.1.2.2 | Contratar | 2h | 2021-01-25 | 2021-01-25 | 90 | 2021-01-25 | 2021-01-25 | 2h | 0d |  | Certicámara [0.1%]; Líder Funcional | 2h | 87,500 | 87,500 |
| 92 | 4.1.2.3 | Aprobaciones de Contrato | 2h | 2021-01-25 | 2021-01-26 | 91 | 2021-01-25 | 2021-01-26 | 2h | 0d |  | Certicámara [0.1%]; Firma digital [0.1%]; Líder Funcional | 2h | 108,279 | 108,279 |
| 93 | 4.1.2.4 | Recibir Licencias | 1h | 2021-01-26 | 2021-01-26 | 92 | 2021-01-26 | 2021-01-26 | 1h | 0d |  | Certicámara [0.1%]; Líder Funcional | 1h | 43,750 | 43,750 |
| 94 | 4.1.3 | **Equipos (Impresora, Scanner)** | 3.5d | 2021-01-26 | 2021-01-29 |  | 2021-01-26 | 2021-01-29 | 3.5d | 0d |  |  | 18h | 808,279 | 808,279 |
| 95 | 4.1.3.1 | Seleccionar proveedor | 4h | 2021-01-26 | 2021-01-27 | 93 | 2021-01-26 | 2021-01-27 | 4h | 0d |  | Certicámara [0.1%]; Director de proyecto; Líder Técnico | 8h | 350,000 | 350,000 |
| 96 | 4.1.3.2 | Contratar | 4h | 2021-01-27 | 2021-01-28 | 95 | 2021-01-27 | 2021-01-28 | 4h | 0d |  | Líder Técnico; Certicámara [0.1%] | 4h | 175,000 | 175,000 |
| 97 | 4.1.3.3 | Aprobaciones de Contrato | 2h | 2021-01-28 | 2021-01-28 | 96 | 2021-01-28 | 2021-01-28 | 2h | 0d |  | Líder Técnico; Certicámara [0.1%]; Firma digital [0.1%] | 2h | 108,279 | 108,279 |
| 98 | 4.1.3.4 | Recibir Impresora y Scanner | 4h | 2021-01-29 | 2021-01-29 | 97 | 2021-01-29 | 2021-01-29 | 4h | 0d |  | Líder Técnico; Certicámara [0.1%] | 4h | 175,000 | 175,000 |
| 99 | 4.1.4 | **Licencias de Correo electrónico** | 3d | 2021-02-01 | 2021-02-03 |  | 2021-02-01 | 2021-02-03 | 3d | 0d |  |  | 16h | 720,779 | 720,779 |
| 100 | 4.1.4.1 | Seleccionar proveedor | 4h | 2021-02-01 | 2021-02-01 | 98 | 2021-02-01 | 2021-02-01 | 4h | 0d |  | Certicámara [0.1%]; Director de proyecto; Líder Funcional | 8h | 350,000 | 350,000 |
| 101 | 4.1.4.2 | Contratar | 4h | 2021-02-02 | 2021-02-02 | 100 | 2021-02-02 | 2021-02-02 | 4h | 0d |  | Certicámara [0.1%]; Líder Funcional | 4h | 175,000 | 175,000 |
| 102 | 4.1.4.3 | Aprobaciones de Contrato | 2h | 2021-02-03 | 2021-02-03 | 101 | 2021-02-03 | 2021-02-03 | 2h | 0d |  | Certicámara [0.1%]; Firma digital [0.1%]; Líder Funcional | 2h | 108,279 | 108,279 |
| 103 | 4.1.4.4 | Recibir Cuentas de Correo Electrónico | 2h | 2021-02-03 | 2021-02-03 | 102 | 2021-02-03 | 2021-02-03 | 2h | 0d |  | Certicámara [0.1%]; Líder Funcional | 2h | 87,500 | 87,500 |
| 104 | 4.2 | **Diagnóstico del proceso de implementación** | 50.5d | 2021-02-04 | 2021-04-20 |  | 2021-02-04 | 2021-04-20 | 50.5d | 0d |  |  | 248.5h | 19,792,559 | 19,792,559 |
| 105 | 4.2.1 | **Información consolidada** | 37.62d | 2021-02-04 | 2021-03-30 |  | 2021-02-04 | 2021-03-30 | 37.62d | 0d |  |  | 134.5h | 10,938,440 | 10,938,440 |
| 106 | 4.2.1.1 | **Metodologías actuales** | 8d | 2021-02-04 | 2021-02-15 |  | 2021-02-04 | 2021-02-15 | 8d | 0d |  |  | 55h | 4,207,648 | 4,207,648 |
| 107 | 4.2.1.1.1 | Checklist para levantamiento de información | 7h | 2021-02-04 | 2021-02-05 | 88, 93, 98, 103 | 2021-02-04 | 2021-02-05 | 7h | 0d |  | Dotación DP [0.1%]; Director de proyecto; Líder Funcional; Líder Técnico; Dotación LF [0.1%]; Dotación LT [0.1%] | 21h | 1,562,849 | 1,562,849 |
| 108 | 4.2.1.1.2 | Sesión de entendimiento con área de Implementación | 4h | 2021-02-05 | 2021-02-08 | 107 | 2021-02-05 | 2021-02-08 | 4h | 0d |  | Director de proyecto; Dotación DP [0.1%] | 4h | 392,650 | 392,650 |
| 109 | 4.2.1.1.3 | Sesión de entendimiento con área comercial | 4h | 2021-02-08 | 2021-02-09 | 108 | 2021-02-08 | 2021-02-09 | 4h | 6.62d | 0d | Dotación LF [0.1%]; Líder Funcional | 4h | 232,276 | 232,276 |
| 110 | 4.2.1.1.4 | Sesión de entendimiento con área Juridica | 4h | 2021-02-05 | 2021-02-08 | 107 | 2021-02-05 | 2021-02-08 | 4h | 9.38d | 0d | Líder Técnico; Dotación LT [0.1%] | 4h | 291,413 | 291,413 |
| 111 | 4.2.1.1.5 | Sesión de entendimiento con área Tecnologia | 4h | 2021-02-08 | 2021-02-09 | 108 | 2021-02-08 | 2021-02-09 | 4h | 9.38d | 2.75d | Dotación DP [0.1%]; Director de proyecto | 4h | 392,650 | 392,650 |
| 112 | 4.2.1.1.6 | Sesión de entendimiento con área Mejoramiento Continuo | 4h | 2021-02-09 | 2021-02-10 | 109 | 2021-02-09 | 2021-02-10 | 4h | 6.62d | 0d | Líder Funcional; Dotación LF [0.1%] | 4h | 232,276 | 232,276 |
| 113 | 4.2.1.1.7 | Sesión de entendimiento con área Producto | 4h | 2021-02-08 | 2021-02-09 | 110 | 2021-02-08 | 2021-02-09 | 4h | 9.38d | 2.75d | Líder Técnico; Dotación LT [0.1%] | 4h | 268,131 | 268,131 |
| 114 | 4.2.1.1.8 | Sesión de entendimiento con área Soporte | 4h | 2021-02-10 | 2021-02-12 | 112 | 2021-02-10 | 2021-02-12 | 4h | 6.62d | 0d | Director de proyecto; Dotación DP [0.1%] | 4h | 392,650 | 392,650 |
| 115 | 4.2.1.1.9 | Elaborar informe | 6h | 2021-02-12 | 2021-02-15 | 107, 109, 108, 110, 111, 112, 113, 114 | 2021-02-12 | 2021-02-15 | 6h | 6.62d | 0d | Líder Funcional; Scanner [0.1%]; Dotación LF [0.1%]; Hojas tamaño carta [0.1%]; Impresora [0.1%] | 6h | 442,753 | 442,753 |

| ID | WBS | Task | Duration | Start | Finish | Predecessors | Baseline start | Baseline finish | Baseline duration | Total slack | Free slack | Resources | Work | Cost | Baseline cost |
| --- | --- | --- | --- | --- | --- | --- | --- | --- | --- | --- | --- | --- | --- | --- | --- |
| 116 | 4.2.1.2 | **Presupuesto ejecutado costos actuales** | 15d | 2021-02-16 | 2021-03-09 |  | 2021-02-16 | 2021-03-09 | 15d | 16.38d |  |  | 23h | 1,805,666 | 1,805,666 |
| 117 | 4.2.1.2.1 | Sesión con área Comercial | 2.5h | 2021-02-16 | 2021-02-24 | 109 | 2021-02-16 | 2021-02-24 | 2.5h | 16.38d | 0d | Scanner [0.1%]; Dotación LF [0.1%]; Hojas tamaño carta [0.1%]; Marcadores para tablero [0.1%]; Impresora [0.1%]; Líder Funcional | 2.5h | 187,013 | 187,013 |
| 118 | 4.2.1.2.2 | Revision propuestas comerciales realizadas para clientes | 11h | 2021-02-24 | 2021-03-01 | 117 | 2021-02-24 | 2021-03-01 | 11h | 16.38d | 0d | Scanner [0.1%]; Dotación LF [0.1%]; Hojas tamaño carta [0.1%]; Impresora [0.1%]; Líder Funcional; Marcadores para tablero [0.1%] | 11h | 822,853 | 822,853 |
| 119 | 4.2.1.2.3 | Sesión con área Comercial | 2.5h | 2021-03-01 | 2021-03-02 | 118 | 2021-03-01 | 2021-03-02 | 2.5h | 16.38d | 0d | Scanner [0.1%]; Hojas tamaño carta [0.1%]; Marcadores para tablero [0.1%]; Impresora [0.1%]; Líder Técnico; Dotación LT [0.1%] | 2.5h | 209,422 | 209,422 |
| 120 | 4.2.1.2.4 | Sesión I con área Financiera | 3.5h | 2021-03-02 | 2021-03-03 | 119 | 2021-03-02 | 2021-03-03 | 3.5h | 16.38d | 0d | Scanner [0.1%]; Hojas tamaño carta [0.1%]; Marcadores para tablero [0.1%]; Impresora [0.1%]; Dotación LT [0.1%]; Líder Técnico | 3.5h | 293,189 | 293,189 |
| 121 | 4.2.1.2.5 | Sesión II con área Financiera | 3.5h | 2021-03-03 | 2021-03-09 | 120 | 2021-03-03 | 2021-03-09 | 3.5h | 200.38d |  | Scanner [0.1%]; Hojas tamaño carta [0.1%]; Marcadores para tablero [0.1%]; Impresora [0.1%]; Dotación LT [0.1%]; Líder Técnico | 3.5h | 293,189 | 293,189 |
| 122 | 4.2.1.3 | **Cronograma tiempos actuales** | 34.88d | 2021-02-08 | 2021-03-30 |  | 2021-02-08 | 2021-03-30 | 34.88d | 0d |  |  | 27.5h | 2,510,664 | 2,510,664 |
| 123 | 4.2.1.3.1 | Sesión I con colaboradores del área de implementación | 6h | 2021-02-08 | 2021-02-16 | 108 | 2021-02-08 | 2021-02-16 | 6h | 0d |  | Scanner [0.1%]; Hojas tamaño carta [0.1%]; Marcadores para tablero [0.1%]; Impresora [0.1%]; Director de proyecto; Dotación DP [0.1%] | 6h | 689,389 | 689,389 |
| 124 | 4.2.1.3.2 | Sesión I con área juridica encargada de elaboración de contratos de implementaciones con clientes. | 2.5h | 2021-02-16 | 2021-03-02 | 123 | 2021-02-16 | 2021-03-02 | 2.5h | 0d |  | Scanner [0.1%]; Hojas tamaño carta [0.1%]; Líder Técnico; Dotación LT [0.1%]; Impresora [0.1%] | 2.5h | 206,891 | 206,891 |
| 125 | 4.2.1.3.3 | Sesión de evaluación de tiempos con líder de Implementación | 1h | 2021-03-03 | 2021-03-03 | 124 | 2021-03-03 | 2021-03-03 | 1h | 0d |  | Dotación DP [0.1%]; Director de proyecto | 1h | 98,162 | 98,162 |
| 126 | 4.2.1.3.4 | Sesión de evaluación de tiempos con líder de Comercial | 1h | 2021-03-03 | 2021-03-04 | 125 | 2021-03-03 | 2021-03-04 | 1h | 0d |  | Líder Funcional; Dotación LF [0.1%] | 1h | 58,069 | 58,069 |
| 127 | 4.2.1.3.5 | Sesión de evaluación de tiempos con líder de Jurídica | 1h | 2021-03-04 | 2021-03-05 | 126 | 2021-03-04 | 2021-03-05 | 1h | 0d |  | Líder Técnico; Dotación LT [0.1%] | 1h | 67,033 | 67,033 |
| 128 | 4.2.1.3.6 | Sesión de evaluación de tiempos con líder de Tecnología | 1h | 2021-03-05 | 2021-03-05 | 127 | 2021-03-05 | 2021-03-05 | 1h | 0d |  | Dotación DP [0.1%]; Director de proyecto | 1h | 98,162 | 98,162 |
| 129 | 4.2.1.3.7 | Sesión de evaluación de tiempos con líder de Mejoramiento continuo | 1h | 2021-03-08 | 2021-03-11 | 128 | 2021-03-08 | 2021-03-11 | 1h | 0d |  | Líder Funcional; Dotación LF [0.1%] | 1h | 58,069 | 58,069 |
| 130 | 4.2.1.3.8 | Sesión de evaluación de tiempos con líder de Producto | 1h | 2021-03-11 | 2021-03-12 | 129 | 2021-03-11 | 2021-03-12 | 1h | 0d |  | Líder Técnico; Dotación LT [0.1%] | 1h | 67,033 | 67,033 |
| 131 | 4.2.1.3.9 | Sesión de evaluación de tiempos con líder de Soporte | 1h | 2021-03-12 | 2021-03-15 | 130 | 2021-03-12 | 2021-03-15 | 1h | 0d |  | Líder Funcional; Dotación LF [0.1%] | 1h | 58,069 | 58,069 |
| 132 | 4.2.1.3.10 | Sesión II con colaboradores del área de implementación | 6h | 2021-03-15 | 2021-03-25 | 131 | 2021-03-15 | 2021-03-25 | 6h | 0d |  | Scanner [0.1%]; Hojas tamaño carta [0.1%]; Marcadores para tablero [0.1%]; Líder Técnico; Dotación LT [0.1%]; Impresora [0.1%] | 6h | 502,610 | 502,610 |
| 133 | 4.2.1.3.11 | Sesión II con área juridica encargada de elaboración de contratos de implementaciones con clientes. | 2h | 2021-03-25 | 2021-03-30 | 132 | 2021-03-25 | 2021-03-30 | 2h | 186d |  | Scanner [0.1%]; Hojas tamaño carta [0.1%]; Impresora [0.1%]; Líder Funcional; Dotación LF [0.1%] | 2h | 147,585 | 147,585 |
| 134 | 4.2.1.3.12 | Consolidar tiempo total por implementación | 4h | 2021-03-25 | 2021-03-26 | 132 | 2021-03-25 | 2021-03-26 | 4h | 0d |  | Scanner [0.1%]; Hojas tamaño carta [0.1%]; Marcadores para tablero [0.1%]; Dotación DP [0.1%]; Director de proyecto; Impresora [0.1%] | 4h | 459,592 | 459,592 |
| 135 | 4.2.1.4 | **Diagrama de interacciones** | 26.75d | 2021-02-16 | 2021-03-25 |  | 2021-02-16 | 2021-03-25 | 26.75d | 0.75d |  |  | 29h | 2,414,462 | 2,414,462 |
| 136 | 4.2.1.4.1 | Revisión matriz RACI del proceso actual | 5h | 2021-03-03 | 2021-03-08 | 125 | 2021-03-03 | 2021-03-08 | 5h | 0.75d | 0d | Líder Técnico; Dotación LT [0.1%] | 5h | 335,163 | 335,163 |
| 137 | 4.2.1.4.2 | Análisis de matriz RACI | 9h | 2021-03-08 | 2021-03-25 | 136 | 2021-03-08 | 2021-03-25 | 9h | 0.75d |  | Director de proyecto; Dotación DP [0.1%] | 9h | 883,462 | 883,462 |
| 138 | 4.2.1.4.3 | Elaboración de encuestas a las involucrados | 6h | 2021-02-16 | 2021-02-18 | 115 | 2021-02-16 | 2021-02-18 | 6h | 6.62d | 0d | Líder Funcional; Dotación LF [0.1%] | 6h | 348,414 | 348,414 |
| 139 | 4.2.1.4.4 | Análisis de resultados de las encuestas | 9h | 2021-02-22 | 2021-03-16 | 138FS+2d | 2021-02-22 | 2021-03-16 | 9h | 6.62d |  | Líder Técnico; Dotación LT [0.1%]; Impresora [0.1%]; Scanner [0.1%]; Hojas tamaño carta [0.1%]; Marcadores para tablero [0.1%]; Firma digital [0.1%] | 9h | 847,423 | 847,423 |

| ID | WBS | Task | Duration | Start | Finish | Predecessors | Baseline start | Baseline finish | Baseline duration | Total slack | Free slack | Constraint | Resources | Work | Cost | Baseline cost |
| --- | --- | --- | --- | --- | --- | --- | --- | --- | --- | --- | --- | --- | --- | --- | --- | --- |
| 140 | 4.2.2 | **Análisis** | 16d | 2021-03-25 | 2021-04-20 |  | 2021-03-25 | 2021-04-20 | 16d | 1d |  |  |  | 114h | 8,854,119 | 8,854,119 |
| 141 | 4.2.2.1 | **Funcionamiento del proceso** | 6d | 2021-03-25 | 2021-04-06 |  | 2021-03-25 | 2021-04-06 | 6d | 0d |  |  |  | 36h | 2,848,806 | 2,848,806 |
| 142 | 4.2.2.1.1 | Análisis de información obtenida en sesiones con las áreas de levantamiento de información | 9h | 2021-03-26 | 2021-03-30 | 118, 120, 137, 139, 134 | 2021-03-26 | 2021-03-30 | 9h | 0d |  |  | Líder Técnico; Dotación LT [0.1%]; Dotación DP [0.1%]; Director de proyecto; Líder Funcional; Dotación LF [0.1%]; Marcadores para tablero [0.1%] | 27h | 2,018,491 | 2,018,491 |
| 143 | 4.2.2.1.2 | Análisis de datos obtenidos en referencias a implementaciones del último año | 7h | 2021-03-30 | 2021-04-06 | 142 | 2021-03-30 | 2021-04-06 | 7h | 0d |  |  | Marcadores para tablero [0.1%]; Director de proyecto; Dotación DP [0.1%] | 7h | 694,225 | 694,225 |
| 144 | 4.2.2.1.3 | Análisis de documentos de lecciones aprendidas | 2h | 2021-03-25 | 2021-03-30 | 123, 132 | 2021-03-25 | 2021-03-30 | 2h | 2.88d |  |  | Líder Técnico; Dotación LT [0.1%]; Marcadores para tablero [0.1%] | 2h | 136,090 | 136,090 |
| 145 | 4.2.2.2 | **Informe del estado actual** | 10d | 2021-04-06 | 2021-04-20 |  | 2021-04-06 | 2021-04-20 | 10d | 0d |  |  |  | 78h | 6,005,313 | 6,005,313 |
| 146 | 4.2.2.2.1 | Consolidación de la información analizada | 15h | 2021-04-06 | 2021-04-12 | 142, 143, 144 | 2021-04-06 | 2021-04-12 | 15h | 0d |  |  | Dotación LT [0.1%]; Líder Técnico; Dotación DP [0.1%]; Director de proyecto; Líder Funcional; Dotación LF [0.1%]; Firma digital [0.1%] | 45h | 3,504,807 | 3,504,807 |
| 147 | 4.2.2.2.2 | Definición de conclusiones de la informacion analizada y el levantamiento de la informacíon | 7h | 2021-04-12 | 2021-04-13 | 146 | 2021-04-12 | 2021-04-13 | 7h | 0d |  |  | Líder Técnico; Dotación LT [0.1%]; Dotación DP [0.1%]; Director de proyecto; Líder Funcional; Dotación LF [0.1%]; Marcadores para tablero [0.1%] | 21h | 1,569,937 | 1,569,937 |
| 148 | 4.2.2.2.3 | Elaboración del informe de estado actual del proceso de implementación | 5h | 2021-04-14 | 2021-04-15 | 147 | 2021-04-14 | 2021-04-15 | 5h | 0d |  |  | Impresora [0.1%]; Líder Funcional; Scanner [0.1%]; Dotación LF [0.1%]; Hojas tamaño carta [0.1%]; Marcadores para tablero [0.1%]; Firma digital [0.1%] | 5h | 425,972 | 425,972 |
| 149 | 4.2.2.2.4 | **Jornadas de seguimiento con representantes de todas las áreas** | 2.75d | 2021-04-15 | 2021-04-20 |  | 2021-04-15 | 2021-04-20 | 2.75d | 12.38d |  |  |  | 7h | 504,597 | 504,597 |
| 150 | 4.2.2.2.4.1 | Seguimiento con líder de Implementación | 1h | 2021-04-15 | 2021-04-16 | 148 | 2021-04-15 | 2021-04-16 | 1h | 12.38d | 0d |  | Director de proyecto; Dotación DP [0.1%] | 1h | 98,162 | 98,162 |
| 151 | 4.2.2.2.4.2 | Seguimiento con líder de Comercial | 1h | 2021-04-16 | 2021-04-16 | 150 | 2021-04-16 | 2021-04-16 | 1h | 12.38d | 0d |  | Dotación LF [0.1%]; Líder Funcional | 1h | 58,069 | 58,069 |
| 152 | 4.2.2.2.4.3 | Seguimiento con líder de Jurídica | 1h | 2021-04-16 | 2021-04-16 | 151 | 2021-04-16 | 2021-04-16 | 1h | 12.38d | 0d |  | Dotación LT [0.1%]; Líder Técnico | 1h | 67,033 | 67,033 |
| 153 | 4.2.2.2.4.4 | Seguimiento con líder de Tecnología | 1h | 2021-04-16 | 2021-04-16 | 152 | 2021-04-16 | 2021-04-16 | 1h | 12.38d | 0d |  | Director de proyecto; Dotación DP [0.1%] | 1h | 98,162 | 98,162 |
| 154 | 4.2.2.2.4.5 | Seguimiento con líder de Mejoramiento continuo | 1h | 2021-04-16 | 2021-04-19 | 153 | 2021-04-16 | 2021-04-19 | 1h | 12.38d | 0d |  | Dotación LF [0.1%]; Líder Funcional | 1h | 58,069 | 58,069 |
| 155 | 4.2.2.2.4.6 | Seguimiento con líder de Producto | 1h | 2021-04-19 | 2021-04-20 | 154 | 2021-04-19 | 2021-04-20 | 1h | 12.38d | 0d |  | Dotación LT [0.1%]; Líder Técnico | 1h | 67,033 | 67,033 |
| 156 | 4.2.2.2.4.7 | Seguimiento con líder de Soporte | 1h | 2021-04-20 | 2021-04-20 | 155 | 2021-04-20 | 2021-04-20 | 1h | 12.38d | 0d |  | Dotación LF [0.1%]; Líder Funcional | 1h | 58,069 | 58,069 |
| 157 | 4.3 | **Estrategia** | 50d | 2021-04-15 | 2021-06-29 |  | 2021-04-15 | 2021-06-29 | 50d | 0d |  |  |  | 205h | 16,968,197.86 | 16,968,197.86 |
| 158 | 4.3.1 | **Documento de estructuración estratégica** | 50d | 2021-04-15 | 2021-06-29 |  | 2021-04-15 | 2021-06-29 | 50d | 0d |  |  |  | 205h | 16,968,197.86 | 16,968,197.86 |
| 159 | 4.3.1.1 | **Líneas de trabajo** | 29.75d | 2021-04-20 | 2021-06-02 |  | 2021-04-20 | 2021-06-02 | 29.75d | 12.38d |  |  |  | 45h | 3,629,917.86 | 3,629,917.86 |
| 160 | 4.3.1.1.1 | Análisis de la información del diagnóstico | 11h | 2021-04-20 | 2021-04-27 | 156 | 2021-04-20 | 2021-04-27 | 11h | 12.38d | 0d |  | Dotación LF [0.1%]; Líder Funcional | 11h | 638,760 | 638,760 |
| 161 | 4.3.1.1.2 | Reunión con las áreas involucradas | 6h | 2021-04-28 | 2021-04-30 | 160 | 2021-04-28 | 2021-04-30 | 6h | 164.88d |  |  | Dotación DP [0.1%]; Director de proyecto | 6h | 588,975 | 588,975 |
| 162 | 4.3.1.1.3 | **Jornadas de seguimiento con representantes de todas las áreas** | 7.88d | 2021-04-28 | 2021-05-07 |  | 2021-04-28 | 2021-05-07 | 7.88d | 12.38d |  |  |  | 7h | 504,697 | 504,697 |
| 163 | 4.3.1.1.3.1 | Seguimiento con líder de Implementación | 1h | 2021-04-28 | 2021-04-28 | 160 | 2021-04-28 | 2021-04-28 | 1h | 12.38d | 0d |  | Dotación DP [0.1%]; Director de proyecto | 1h | 98,162 | 98,162 |
| 164 | 4.3.1.1.3.2 | Seguimiento con líder de Comercial | 1h | 2021-04-28 | 2021-04-28 | 163 | 2021-04-28 | 2021-04-28 | 1h | 12.38d | 0d |  | Líder Funcional; Dotación LF [0.1%] | 1h | 58,069 | 58,069 |
| 165 | 4.3.1.1.3.3 | Seguimiento con líder de Jurídica | 1h | 2021-04-28 | 2021-04-28 | 164 | 2021-04-28 | 2021-04-28 | 1h | 12.38d | 0d |  | Líder Técnico; Dotación LT [0.1%] | 1h | 67,033 | 67,033 |
| 166 | 4.3.1.1.3.4 | Seguimiento con líder de Tecnología | 1h | 2021-04-28 | 2021-04-28 | 165 | 2021-04-28 | 2021-04-28 | 1h | 12.38d | 0d |  | Dotación DP [0.1%]; Director de proyecto | 1h | 98,162 | 98,162 |
| 167 | 4.3.1.1.3.5 | Seguimiento con líder de Mejoramiento continuo | 1h | 2021-04-29 | 2021-04-30 | 166 | 2021-04-29 | 2021-04-30 | 1h | 12.38d | 0d |  | Líder Funcional; Dotación LF [0.1%] | 1h | 58,069 | 58,069 |
| 168 | 4.3.1.1.3.6 | Seguimiento con líder de Producto | 1h | 2021-05-03 | 2021-05-06 | 167 | 2021-05-03 | 2021-05-06 | 1h | 12.38d | 0d |  | Líder Técnico; Dotación LT [0.1%] | 1h | 67,133 | 67,133 |
| 169 | 4.3.1.1.3.7 | Seguimiento con líder de Soporte | 1h | 2021-05-07 | 2021-05-07 | 168 | 2021-05-07 | 2021-05-07 | 1h | 12.38d | 0d |  | Líder Funcional; Dotación LF [0.1%] | 1h | 58,069 | 58,069 |
| 170 | 4.3.1.1.4 | Retroalimentación | 5h | 2021-05-07 | 2021-05-12 | 169 | 2021-05-07 | 2021-05-12 | 5h | 12.38d |  |  | Dotación DP [0.1%]; Director de proyecto; Impresora [0.1%]; Líder Funcional; Líder Técnico; Scanner [0.1%]; Dotación LF [0.1%]; Dotación LT [0.1%]; Hojas tamaño carta [0.1%]; Marcadores para tablero [0.1%] | 15h | 1,199,986.91 | 1,199,986.91 |
| 171 | 4.3.1.1.5 | Definición de las líneas de trabajo | 4h | 2021-05-31 | 2021-06-02 | 170 | 2021-05-31 | 2021-06-02 | 4h | 0d |  | as late as possible | Dotación DP [0.1%]; Director de proyecto; Impresora [0.1%]; Líder Funcional; Líder Técnico; Scanner [0.1%]; Dotación LF [0.1%]; Dotación LT [0.1%]; Hojas tamaño carta [0.1%]; Marcadores para tablero [0.1%] | 6h | 697,498.95 | 697,498.95 |

| ID | WBS | Task | Type | Duration | Start | Finish | Predecessors | Baseline start | Baseline finish | Baseline duration | Total slack | Free slack | Resources | Work | Cost | Baseline cost |
| --- | --- | --- | --- | --- | --- | --- | --- | --- | --- | --- | --- | --- | --- | --- | --- | --- |
| 172 | 4.3.1.2 | **Entradas y salidas de los procesos** |  | 20.25d | 2021-04-15 | 2021-05-13 |  | 2021-04-15 | 2021-05-13 | 20.25d | 0d |  |  | 49h | 3,780,937 | 3,780,937 |
| 173 | 4.3.1.2.1 | Diagnóstico preliminar del proceso |  | 7h | 2021-04-15 | 2021-04-20 | 148 | 2021-04-15 | 2021-04-20 | 7h | 0d |  | Impresora [0.1%]; Líder Técnico; Scanner [0.1%]; Dotación LT [0.1%]; Marcadores para tablero [0.1%] | 7h | 585,487 | 585,487 |
| 174 | 4.3.1.2.2 | Análisis del funcionamiento actual del proceso |  | 8h | 2021-04-21 | 2021-04-26 | 173 | 2021-04-21 | 2021-04-26 | 8h | 0d |  | Impresora [0.1%]; Líder Funcional; Líder Técnico; Scanner [0.1%]; Dotación LF [0.1%]; Dotación LT [0.1%]; Hojas tamaño carta [0.1%]; Marcadores para tablero [0.1%] | 16h | 1,134,701 | 1,134,701 |
| 175 | 4.3.1.2.3 | Validación del funcionamiento |  | 5h | 2021-04-26 | 2021-05-12 | 174 | 2021-04-26 | 2021-05-12 | 5h | 0d |  | Dotación DP [0.1%]; Director de proyecto | 5h | 490,812 | 490,812 |
| 176 | 4.3.1.2.4 | Definición de los componentes del proceso |  | 7h | 2021-05-12 | 2021-05-13 | 175 | 2021-05-12 | 2021-05-13 | 7h | 0d |  | Dotación DP [0.1%]; Director de proyecto; Líder Funcional; Líder Técnico; Dotación LF [0.1%]; Dotación LT [0.1%]; Marcadores para tablero [0.1%] | 21h | 1,569,937 | 1,569,937 |
| 177 | 4.3.1.3 | **Alcance de las áreas involucradas** |  | 12.25d | 2021-05-14 | 2021-06-02 |  | 2021-05-14 | 2021-06-02 | 12.25d | 0d |  |  | 47h | 3,710,718 | 3,710,718 |
| 178 | 4.3.1.3.1 | Diagrama de relaciones e interacciones actuales |  | 4h | 2021-05-14 | 2021-05-18 | 176 | 2021-05-14 | 2021-05-18 | 4h | 0d |  | Impresora [0.1%]; Líder Funcional; Líder Técnico; Scanner [0.1%]; Dotación LF [0.1%]; Dotación LT [0.1%]; Marcadores para tablero [0.1%] | 8h | 566,839 | 566,839 |
| 179 | 4.3.1.3.2 | Reunión con las áreas involucradas |  | 6h | 2021-05-18 | 2021-05-21 | 178 | 2021-05-18 | 2021-05-21 | 6h | 0d |  | Impresora [0.1%]; Líder Funcional; Scanner [0.1%]; Dotación LF [0.1%] | 6h | 441,988 | 441,988 |
| 180 | 4.3.1.3.3 | Jornadas de trabajo con representantes de todas las áreas |  | 7h | 2021-05-21 | 2021-05-25 | 179 | 2021-05-21 | 2021-05-25 | 7h | 0d |  | Dotación DP [0.1%]; Director de proyecto; Impresora [0.1%]; Scanner [0.1%]; Hojas tamaño carta [0.1%]; Marcadores para tablero [0.1%] | 7h | 804,288 | 804,288 |
| 181 | 4.3.1.3.4 | Retroalimentación |  | 5h | 2021-05-25 | 2021-05-26 | 180 | 2021-05-25 | 2021-05-26 | 5h | 0d |  | Dotación DP [0.1%]; Director de proyecto; Impresora [0.1%]; Líder Funcional; Líder Técnico; Scanner [0.1%]; Dotación LF [0.1%]; Dotación LT [0.1%]; Hojas tamaño carta [0.1%]; Marcadores para tablero [0.1%] | 15h | 1,199,999 | 1,199,999 |
| 182 | 4.3.1.3.5 | Identificación de puntos de mejora y optimización |  | 6h | 2021-05-26 | 2021-05-28 | 181 | 2021-05-26 | 2021-05-28 | 6h | 0d |  | Líder Técnico; Dotación LT [0.1%] | 6h | 402,196 | 402,196 |
| 183 | 4.3.1.3.6 | Definición del alcance de cada una de las áreas |  | 5h | 2021-05-31 | 2021-06-02 | 182 | 2021-05-31 | 2021-06-02 | 5h | 0d |  | Líder Funcional; Dotación LF [0.1%]; Marcadores para tablero [0.1%] | 5h | 295,408 | 295,408 |
| 184 | 4.3.1.4 | **Estrategia de mejoramiento** |  | 17.5d | 2021-06-02 | 2021-06-29 |  | 2021-06-02 | 2021-06-29 | 17.5d | 0d |  |  | 64h | 5,846,625 | 5,846,625 |
| 185 | 4.3.1.4.1 | Diagnóstico del proceso completo |  | 8h | 2021-06-02 | 2021-06-08 | 171, 175, 183 | 2021-06-02 | 2021-06-08 | 8h | 0d |  | Líder Técnico; Dotación LT [0.1%] | 8h | 536,261 | 536,261 |
| 186 | 4.3.1.4.2 | Informe de conclusiones |  | 6h | 2021-06-08 | 2021-06-09 | 185 | 2021-06-08 | 2021-06-09 | 6h | 0d |  | Dotación DP [0.1%]; Director de proyecto; Marcadores para tablero [0.1%]; Firma digital [0.1%] | 6h | 657,388 | 657,388 |
| 187 | 4.3.1.4.3 | Planteamiento de la estrategia para optimizar el proceso |  | 30h | 2021-06-10 | 2021-06-22 | 186 | 2021-06-10 | 2021-06-22 | 30h | 0d |  | Dotación DP [0.1%]; Director de proyecto; Marcadores para tablero [0.1%] | 30h | 2,975,248 | 2,975,248 |
| 188 | 4.3.1.4.4 | Conciliación de la estrategia con las áreas funcionales |  | 8h | 2021-06-22 | 2021-06-25 | 187 | 2021-06-22 | 2021-06-25 | 8h | 0d |  | Impresora [0.1%]; Líder Funcional; Scanner [0.1%]; Dotación LF [0.1%]; Hojas tamaño carta [0.1%]; Marcadores para tablero [0.1%] | 8h | 598,440 | 598,440 |
| 189 | 4.3.1.4.5 | Presentación de la estrategia propuesta al equipo/sponsor |  | 5h | 2021-06-25 | 2021-06-28 | 188 | 2021-06-25 | 2021-06-28 | 5h | 0d |  | Dotación DP [0.1%]; Director de proyecto; Impresora [0.1%]; Scanner [0.1%]; Hojas tamaño carta [0.1%]; Marcadores para tablero [0.1%] | 5h | 574,491 | 574,491 |
| 190 | 4.3.1.4.6 | Aprobación de estrategia | milestone | 0h | 2021-06-28 | 2021-06-28 | 189 | 2021-06-28 | 2021-06-28 | 0h | 0d |  |  |  |  |  |
| 191 | 4.3.1.4.7 | **Jornadas de seguimiento con representantes de todas las áreas** |  | 14.25d | 2021-06-08 | 2021-06-29 |  | 2021-06-08 | 2021-06-29 | 14.25d | 125.88d |  |  | 7h | 504,797 | 504,797 |
| 192 | 4.3.1.4.7.1 | Seguimiento con líder de Implementación |  | 1h | 2021-06-29 | 2021-06-29 | 189 | 2021-06-29 | 2021-06-29 | 1h | 125.88d | 0d | Dotación DP [0.1%]; Director de proyecto | 1h | 98,162 | 98,162 |
| 193 | 4.3.1.4.7.2 | Seguimiento con líder de Comercial |  | 1h | 2021-06-25 | 2021-06-28 | 188 | 2021-06-25 | 2021-06-28 | 1h | 126.62d | 0d | Líder Funcional; Dotación LF [0.1%] | 1h | 58,069 | 58,069 |
| 194 | 4.3.1.4.7.3 | Seguimiento con líder de Jurídica |  | 1h | 2021-06-08 | 2021-06-09 | 185 | 2021-06-08 | 2021-06-09 | 1h | 131.88d | 0d | Líder Técnico; Dotación LT [0.1%] | 1h | 67,133 | 67,133 |
| 195 | 4.3.1.4.7.4 | Seguimiento con líder de Tecnología |  | 1h | 2021-06-29 | 2021-06-29 | 192 | 2021-06-29 | 2021-06-29 | 1h | 125.88d |  | Dotación DP [0.1%]; Director de proyecto | 1h | 98,162 | 98,162 |
| 196 | 4.3.1.4.7.5 | Seguimiento con líder de Mejoramiento continuo |  | 1h | 2021-06-28 | 2021-06-28 | 193 | 2021-06-28 | 2021-06-28 | 1h | 126.62d |  | Líder Funcional; Dotación LF [0.1%] | 1h | 58,069 | 58,069 |
| 197 | 4.3.1.4.7.6 | Seguimiento con líder de Producto |  | 1h | 2021-06-09 | 2021-06-09 | 194 | 2021-06-09 | 2021-06-09 | 1h | 131.88d | 0d | Líder Técnico; Dotación LT [0.1%] | 1h | 67,133 | 67,133 |
| 198 | 4.3.1.4.7.7 | Seguimiento con líder de Soporte |  | 1h | 2021-06-09 | 2021-06-21 | 197 | 2021-06-09 | 2021-06-21 | 1h | 131.88d | 74.88d | Líder Funcional; Dotación LF [0.1%] | 1h | 58,069 | 58,069 |

| ID | WBS | Task | Type | Duration | Start | Finish | Predecessors | Baseline start | Baseline finish | Baseline duration | Total slack | Free slack | Resources | Work | Cost | Baseline cost |
| --- | --- | --- | --- | --- | --- | --- | --- | --- | --- | --- | --- | --- | --- | --- | --- | --- |
| 199 | 4.4 | **Nuevo Proceso** |  | 124.12d | 2021-06-29 | 2022-01-24 |  | 2021-06-29 | 2022-01-24 | 124.12d | 0d |  |  | 489h | 36,114,377 | 36,114,377 |
| 200 | 4.4.1 | **Modelo** |  | 124.12d | 2021-06-29 | 2022-01-24 |  | 2021-06-29 | 2022-01-24 | 124.12d | 0d |  |  | 489h | 36,114,377 | 36,114,377 |
| 201 | 4.4.1.1 | **Proceso** |  | 90.12d | 2021-06-29 | 2021-11-09 |  | 2021-06-29 | 2021-11-09 | 90.12d | 0d |  |  | 379h | 28,346,819 | 28,346,819 |
| 202 | 4.4.1.1.1 | **Formatos** |  | 34.25d | 2021-06-29 | 2021-08-19 |  | 2021-06-29 | 2021-08-19 | 34.25d | 0d |  |  | 142h | 10,279,298 | 10,279,298 |
| 203 | 4.4.1.1.1.1 | Implementación de metodología seleccionada para la creación de formatos |  | 30h | 2021-06-29 | 2021-07-15 | 190 | 2021-06-29 | 2021-07-15 | 30h | 0d |  | Líder Funcional; Líder Técnico; Dotación LF [0.1%]; Dotación LT [0.1%] | 60h | 3,753,052 | 3,753,052 |
| 204 | 4.4.1.1.1.2 | Creación de documentos ajustados a las necesidades del proyecto |  | 35h | 2021-07-16 | 2021-08-05 | 203 | 2021-07-16 | 2021-08-05 | 35h | 0d |  | Líder Técnico; Dotación LT [0.1%]; Marcadores para tablero [0.1%]; Director de proyecto; Dotación DP [0.1%] | 70h | 5,817,267 | 5,817,267 |
| 205 | 4.4.1.1.1.3 | Estandarización de los formatos creados según SGC |  | 12h | 2021-08-06 | 2021-08-19 | 204 | 2021-08-06 | 2021-08-19 | 12h | 0d |  | Líder Funcional; Dotación LF [0.1%]; Marcadores para tablero [0.1%] | 12h | 708,979 | 708,979 |
| 206 | 4.4.1.1.1.4 | Aprobación de formatos inerentes a los procedimientos | milestone | 0h | 2021-08-19 | 2021-08-19 | 205 | 2021-08-19 | 2021-08-19 | 0h | 0d |  | Certicámara |  |  |  |
| 207 | 4.4.1.1.2 | **Manuales** |  | 36.38d | 2021-08-19 | 2021-10-08 |  | 2021-08-19 | 2021-10-08 | 36.38d | 0d |  |  | 136h | 10,712,463 | 10,712,463 |
| 208 | 4.4.1.1.2.1 | Verificación de la forma correcta mediante la cual se debe realizar las diferentes actividades de los procesos |  | 8h | 2021-08-19 | 2021-08-24 | 206 | 2021-08-19 | 2021-08-24 | 8h | 0d |  | Líder Funcional; Líder Técnico; Dotación LF [0.1%]; Dotación LT [0.1%]; Marcadores para tablero [0.1%] | 16h | 1,008,914 | 1,008,914 |
| 209 | 4.4.1.1.2.2 | Creación de documento detallado de los pasos mediante los cuales se deben realizar los procedimientos |  | 60h | 2021-08-24 | 2021-10-08 | 208 | 2021-08-24 | 2021-10-08 | 60h | 56d |  | Marcadores para tablero [0.1%]; Director de proyecto; Dotación DP [0.1%] | 60h | 5,920,122 | 5,920,122 |
| 210 | 4.4.1.1.2.3 | Implementación de metodología seleccionada para la creación de manuales |  | 30h | 2021-08-24 | 2021-09-09 | 208 | 2021-08-24 | 2021-09-09 | 30h | 0d |  | Líder Funcional; Líder Técnico; Dotación LF [0.1%]; Dotación LT [0.1%]; Marcadores para tablero [0.1%] | 60h | 3,783,427 | 3,783,427 |
| 211 | 4.4.1.1.2.4 | Aprobación de las actividades documentadas | milestone | 0h | 2021-09-09 | 2021-09-09 | 210 | 2021-09-09 | 2021-09-09 | 0h | 0d |  | Certicámara |  |  |  |
| 212 | 4.4.1.1.3 | **Procedimientos** |  | 20.62d | 2021-09-09 | 2021-10-08 |  | 2021-09-09 | 2021-10-08 | 20.62d | 0d |  |  | 60h | 4,052,457 | 4,052,457 |
| 213 | 4.4.1.1.3.1 | Recopilación y documentación de la información de los procedimientos existentes para la creación del nuevo proceso |  | 14h | 2021-09-09 | 2021-09-20 | 211 | 2021-09-09 | 2021-09-20 | 14h | 0d |  | Líder Funcional; Líder Técnico; Dotación LF [0.1%]; Dotación LT [0.1%]; Marcadores para tablero [0.1%] | 28h | 1,765,599 | 1,765,599 |
| 214 | 4.4.1.1.3.2 | Evaluación de indicadores de gestión y respuesta oportuna de los procedimientos |  | 8h | 2021-09-20 | 2021-09-29 | 213 | 2021-09-20 | 2021-09-29 | 8h | 0d |  | Líder Funcional; Dotación LF [0.1%] | 8h | 464,553 | 464,553 |
| 215 | 4.4.1.1.3.3 | Documentación de procedimientos con las respectivas mejoras |  | 7h | 2021-09-30 | 2021-10-05 | 214 | 2021-09-30 | 2021-10-05 | 7h | 0d |  | Director de proyecto; Dotación DP [0.1%] | 7h | 687,137 | 687,137 |
| 216 | 4.4.1.1.3.4 | Implementación de metodología seleccionada para la creación de procedimientos |  | 5h | 2021-10-05 | 2021-10-07 | 215 | 2021-10-05 | 2021-10-07 | 5h | 0d |  | Líder Funcional; Líder Técnico; Dotación LF [0.1%]; Dotación LT [0.1%]; Marcadores para tablero [0.1%] | 10h | 630,571 | 630,571 |
| 217 | 4.4.1.1.3.5 | Aprobación de procedimientos ajustados al nuevo proceso | milestone | 0h | 2021-10-07 | 2021-10-07 | 216 | 2021-10-07 | 2021-10-07 | 0h | 57d | 0d | Certicámara |  |  |  |
| 218 | 4.4.1.1.3.6 | **Jornadas de seguimiento con representantes de todas las áreas** |  | 0.75d | 2021-10-07 | 2021-10-08 |  | 2021-10-07 | 2021-10-08 | 0.75d | 0d |  |  | 7h | 504,597 | 504,597 |
| 219 | 4.4.1.1.3.6.1 | Seguimiento con líder de Implementación |  | 1h | 2021-10-07 | 2021-10-07 | 217, 198 | 2021-10-07 | 2021-10-07 | 1h | 57d |  | Dotación DP [0.1%]; Director de proyecto | 1h | 98,162 | 98,162 |
| 220 | 4.4.1.1.3.6.2 | Seguimiento con líder de Comercial |  | 1h | 2021-10-07 | 2021-10-07 | 216 | 2021-10-07 | 2021-10-07 | 1h | 0d |  | Líder Funcional; Dotación LF [0.1%] | 1h | 58,069 | 58,069 |
| 221 | 4.4.1.1.3.6.3 | Seguimiento con líder de Jurídica |  | 1h | 2021-10-07 | 2021-10-07 | 216 | 2021-10-07 | 2021-10-07 | 1h | 56.75d | 0d | Líder Técnico; Dotación LT [0.1%] | 1h | 67,033 | 67,033 |
| 222 | 4.4.1.1.3.6.4 | Seguimiento con líder de Tecnología |  | 1h | 2021-10-07 | 2021-10-07 | 221 | 2021-10-07 | 2021-10-07 | 1h | 56.75d |  | Dotación DP [0.1%]; Director de proyecto | 1h | 98,162 | 98,162 |
| 223 | 4.4.1.1.3.6.5 | Seguimiento con líder de Mejoramiento continuo |  | 1h | 2021-10-07 | 2021-10-07 | 220 | 2021-10-07 | 2021-10-07 | 1h | 0d |  | Líder Funcional; Dotación LF [0.1%] | 1h | 58,069 | 58,069 |
| 224 | 4.4.1.1.3.6.6 | Seguimiento con líder de Producto |  | 1h | 2021-10-07 | 2021-10-07 | 221 | 2021-10-07 | 2021-10-07 | 1h | 56.75d |  | Líder Técnico; Dotación LT [0.1%] | 1h | 67,033 | 67,033 |
| 225 | 4.4.1.1.3.6.7 | Seguimiento con líder de Soporte |  | 1h | 2021-10-07 | 2021-10-08 | 223 | 2021-10-07 | 2021-10-08 | 1h | 0d |  | Líder Funcional; Dotación LF [0.1%] | 1h | 58,069 | 58,069 |

| ID | WBS | Task | Type | Duration | Start | Finish | Predecessors | Baseline start | Baseline finish | Baseline duration | Total slack | Resources | Work | Cost | Baseline cost |
| --- | --- | --- | --- | --- | --- | --- | --- | --- | --- | --- | --- | --- | --- | --- | --- |
| 226 | 4.4.1.1.4 | **Documento de roles y responsabilidades** |  | 20d | 2021-10-08 | 2021-11-09 |  | 2021-10-08 | 2021-11-09 | 20d | 0d |  | 41h | 3,302,601 | 3,302,601 |
| 227 | 4.4.1.1.4.1 | Delegación de responsabilidades por áreas |  | 4h | 2021-10-08 | 2021-10-19 | 225 | 2021-10-08 | 2021-10-19 | 4h | 0d | Líder Funcional; Dotación LF [0.1%] | 4h | 232,276 | 232,276 |
| 228 | 4.4.1.1.4.2 | Implementación de metodología seleccionada para la creación de documento de roles y responsabilidades |  | 8h | 2021-10-19 | 2021-10-22 | 227 | 2021-10-19 | 2021-10-22 | 8h | 0d | Líder Funcional; Líder Técnico; Dotación LF [0.1%]; Dotación LT [0.1%]; Marcadores para tablero [0.1%] | 16h | 1,008,914 | 1,008,914 |
| 229 | 4.4.1.1.4.3 | Creación de nuevo organigrama |  | 21h | 2021-10-22 | 2021-11-09 | 228 | 2021-10-22 | 2021-11-09 | 21h | 0d | Director de proyecto; Dotación DP [0.1%] | 21h | 2,061,411 | 2,061,411 |
| 230 | 4.4.1.1.4.4 | Aprobación de organigrama propuesto | milestone | 0h | 2021-11-09 | 2021-11-09 | 229 | 2021-11-09 | 2021-11-09 | 0h | 0d | Certicámara |  |  |  |
| 231 | 4.4.1.2 | **Políticas** |  | 19.5d | 2021-11-09 | 2021-12-07 |  | 2021-11-09 | 2021-12-07 | 19.5d | 0d |  | 49h | 2,935,021 | 2,935,021 |
| 232 | 4.4.1.2.1 | Generación o modificación de las politicas institucionales aplicables al proyecto |  | 39h | 2021-11-09 | 2021-12-01 | 227, 229, 230 | 2021-11-09 | 2021-12-01 | 39h | 0d | Líder Funcional; Dotación LF [0.1%] | 39h | 2,264,694 | 2,264,694 |
| 233 | 4.4.1.2.2 | Estandarización de documentos según la planeación estratégica de la compañía |  | 10h | 2021-12-01 | 2021-12-07 | 232 | 2021-12-01 | 2021-12-07 | 10h | 0d | Líder Técnico; Dotación LT [0.1%] | 10h | 670,327 | 670,327 |
| 234 | 4.4.1.2.3 | Aprobación de documentos | milestone | 0h | 2021-12-07 | 2021-12-07 | 233 | 2021-12-07 | 2021-12-07 | 0h | 0d |  |  |  |  |
| 235 | 4.4.1.3 | **Aprobación** |  | 8.25d | 2022-01-03 | 2022-01-14 |  | 2022-01-03 | 2022-01-14 | 8.25d | 0d |  | 33h | 2,348,576 | 2,348,576 |
| 236 | 4.4.1.3.1 | Creación de informe final con documentación completa |  | 18h | 2022-01-03 | 2022-01-13 | 234FS+1d | 2022-01-03 | 2022-01-13 | 18h | 0d | Líder Funcional; Dotación LF [0.1%]; Firma digital [0.1%] | 18h | 1,232,256 | 1,232,256 |
| 237 | 4.4.1.3.2 | Presentación del informe final |  | 5h | 2022-01-13 | 2022-01-14 | 236 | 2022-01-13 | 2022-01-14 | 5h | 0d | Dotación DP [0.1%]; Director de proyecto; Líder Funcional; Líder Técnico; Dotación LF [0.1%]; Dotación LT [0.1%] | 15h | 1,116,320 | 1,116,320 |
| 238 | 4.4.1.3.3 | Aprobación final del proyecto | milestone | 0h | 2022-01-14 | 2022-01-14 | 237 | 2022-01-14 | 2022-01-14 | 0h | 0d |  |  |  |  |
| 239 | 4.4.1.4 | **Socialización** |  | 5.25d | 2022-01-14 | 2022-01-24 |  | 2022-01-14 | 2022-01-24 | 5.25d | 0d |  | 28h | 2,483,961 | 2,483,961 |
| 240 | 4.4.1.4.1 | Elaboración de la presentación del proyecto aprobado |  | 10h | 2022-01-14 | 2022-01-20 | 238 | 2022-01-14 | 2022-01-20 | 10h | 0d | Director de proyecto; Dotación DP [0.1%] | 10h | 981,624 | 981,624 |
| 241 | 4.4.1.4.2 | Presentación del proyecto aprobado a las áreas involucradas |  | 6h | 2022-01-20 | 2022-01-24 | 240 | 2022-01-20 | 2022-01-24 | 6h | 0d | Dotación DP [0.1%]; Director de proyecto; Impresora [0.1%]; Líder Funcional; Líder Técnico; Scanner [0.1%]; Dotación LF [0.1%]; Dotación LT [0.1%]; Hojas tamaño carta [0.1%]; Marcadores para tablero [0.1%]; Firma digital [0.1%] | 18h | 1,502,337 | 1,502,337 |
| 242 | 5 | **CIERRE** |  | 2.5d | 2022-01-24 | 2022-01-26 |  | 2022-01-24 | 2022-01-26 | 2.5d | 0d |  | 10h | 1,252,877 | 1,252,877 |
| 243 | 5.1 | Elaboracion de acta de cierre |  | 4h | 2022-01-24 | 2022-01-25 | 241 | 2022-01-24 | 2022-01-25 | 4h | 0d | Dotación DP [0.1%]; Director de proyecto; Impresora [0.1%]; Scanner [0.1%]; Firma digital [0.1%]; Hojas tamaño carta [0.1%]; Marcadores para tablero [0.1%] | 4h | 501,150 | 501,150 |
| 244 | 5.2 | Entrega y socialización de acta de cierre |  | 6h | 2022-01-25 | 2022-01-26 | 243 | 2022-01-25 | 2022-01-26 | 6h | 0d | Dotación DP [0.1%]; Director de proyecto; Impresora [0.1%]; Scanner [0.1%]; Firma digital [0.1%]; Hojas tamaño carta [0.1%]; Marcadores para tablero [0.1%] | 6h | 751,727 | 751,727 |
| 245 | 5.3 | Acta de cierre de proyecto firmada | milestone | 0h | 2022-01-26 | 2022-01-26 | 244 | 2022-01-26 | 2022-01-26 | 0h | 0d |  |  |  |  |
| 246 | 6 | FIN | milestone | 0h | 2022-01-26 | 2022-01-26 | 245 | 2022-01-26 | 2022-01-26 | 0h | 0d |  |  |  |  |
